# NLC

Schedule from MS Project, 2007-04-01 to 2008-12-18.
NLC CABLE PLANT

## Calendars

- Standard: Mon-Fri 08:00-12:00, 13:00-17:00; Sat-Sun off. Exceptions (off unless hours are given): 2007-04-01 08:00-12:00, 13:00-17:00.

## Resources

| Resource | Rate |
| --- | --- |
| D. Martin | 50 |
| P. Bellomo | 33 |
| D. Baltazar | 33 |
| P. Rodriguez | 41 |
| L. Johnson | 50 |
| SSRL | 41 |
| SHOP | 33 |

## Schedule

| ID | WBS | Task | Type | Duration | Start | Finish | Predecessors | Baseline start | Baseline finish | Baseline duration | Total slack | Free slack | Constraint | Baseline cost |
| --- | --- | --- | --- | --- | --- | --- | --- | --- | --- | --- | --- | --- | --- | --- |
| 1 | 1 | START | milestone | 0d | 2007-11-29 | 2007-11-29 |  | 1999-11-01 | 1999-11-01 | 246d | 241d |  | start no earlier than 2007-11-29 |  |
| 2 | 2.2 | **LCLS CABLE PLANT INSTALLATION - PHASE 4** |  | 415d | 2007-04-01 | 2008-10-31 |  | 1998-01-12 | 1998-08-15 | 155d | 35d |  |  | 173,840 |
| 3 | 2.2 | **LCLS PH4 BID** |  | 251d | 2007-04-01 | 2008-03-14 |  | 1998-01-12 | 1998-08-15 | 155d | 199d |  |  | 173,840 |
| 4 | 2.2.1.1 | BID PROCESS START | milestone | 0d | 2007-12-13 | 2007-12-13 |  | 2000-05-08 | 2000-06-30 | 40d | 266d |  | start no earlier than 2007-12-13 |  |
| 5 | 2.2.1.1 | Req. in BIS |  | 1d | 2007-12-17 | 2007-12-17 |  | 2000-05-08 | 2000-06-30 | 40d | 263d |  | start no earlier than 2007-12-17 |  |
| 6 | 2.2.1.1 | Management + Budgets Approval |  | 19d | 2007-12-17 | 2008-01-10 |  | 2000-05-08 | 2000-06-30 | 40d | 164d | 0d | finish no earlier than 2008-01-10 |  |
| 7 | 2.2.1.1 | Purchasing + DOE Approval |  | 12d | 2008-01-11 | 2008-01-28 | 6 | 2000-05-08 | 2000-06-30 | 40d | 164d | 1d | finish no earlier than 2008-01-28 |  |
| 8 | 2.2.1.1 | Site Visit |  | 1d | 2008-01-30 | 2008-01-30 | 7 | 2000-05-08 | 2000-06-30 | 40d | 163d | 13d | start no earlier than 2008-01-30 |  |
| 9 | 2.2.1.1 | Bid Opening |  | 1d | 2008-02-19 | 2008-02-19 | 8 | 2000-05-08 | 2000-06-30 | 40d | 150d | 9d | start no earlier than 2008-02-19 |  |
| 10 | 2.2.1.1 | Award |  | 1d | 2008-03-04 | 2008-03-04 | 9 | 2000-05-08 | 2000-06-30 | 40d | 141d | 39d | start no earlier than 2008-03-04 |  |
| 11 | 2.2.1.1 | Kick off Meeting |  | 1d | 2008-03-10 | 2008-03-10 |  | 2000-05-08 | 2000-06-30 | 40d | 203d |  | start no earlier than 2008-03-10 |  |
| 12 | 2.2.1.1 | NTP |  | 1d | 2008-03-14 | 2008-03-14 |  | 2000-05-08 | 2000-06-30 | 40d | 199d |  | start no earlier than 2008-03-14 |  |
| 14 | 2.2.1.1 | CABLE PLANT INSTALLATION START | milestone | 0d | 2007-04-01 | 2007-04-01 |  | 2000-05-08 | 2000-06-30 | 40d | 450d |  | start no earlier than 2007-04-01 |  |
| 16 | 2.2 | **LTU, BTHW, BTH (B911, 912, 913)** |  | 133d | 2008-04-29 | 2008-10-31 | 10 |  |  |  | 35d |  |  |  |
| 17 | 2.2.1 | INSTALL RACKS IN B911, B912, B913 |  | 6d | 2008-04-29 | 2008-05-06 |  |  |  |  | 102d | 0d | start no earlier than 2008-04-29 |  |
| 18 | 2.2.1.1 | INSTALL CABLES FROM B911 |  | 20d | 2008-05-07 | 2008-06-03 | 17 | 2000-05-08 | 2000-06-30 | 40d | 102d | 8d | start no earlier than 2008-05-07 |  |
| 20 | 2.2.1.1 | INSTALL CABLES FROM B912 |  | 24d | 2008-05-19 | 2008-06-19 |  | 2000-05-08 | 2000-06-30 | 40d | 96d | 2d | start no earlier than 2008-05-19 |  |
| 22 | 2.2.1.1 | INSTALL CABLES FROM B913 |  | 27d | 2008-06-16 | 2008-07-22 |  | 2000-05-08 | 2000-06-30 | 40d | 96d | 2d | finish no earlier than 2008-07-22 |  |
| 24 | 2.2.5 | TERMINATE, TAG & TEST CABLES FOR LTU AREAS |  | 40d | 2008-06-16 | 2008-08-08 | 18, 20FS-6d, 22FS-29d |  |  |  | 94d | 59d | start no earlier than 2008-06-16 |  |
| 26 | 2.2.1.1 | **UNDULATOR HALL** |  | 66d | 2008-07-22 | 2008-10-21 | 10 | 2000-05-08 | 2000-06-30 | 40d | 42d |  |  |  |
| 27 | 2.2.1.1 | INSTALL CABLES AT UNDULATOR |  | 50d | 2008-07-22 | 2008-09-29 |  | 2000-05-08 | 2000-06-30 | 40d | 9d | 2d | start no earlier than 2008-07-22 |  |
| 28 | 2.2.1.1 | TERMINATE, TAG & TEST CABLES |  | 18d | 2008-09-26 | 2008-10-21 | 27FS-4d | 2000-05-08 | 2000-06-30 | 40d | 7d |  | start no earlier than 2008-09-26 |  |
| 30 | 2.2.7 | **E-DUMP & B921:** |  | 40d | 2008-08-27 | 2008-10-21 | 10 | 2000-05-08 | 2000-06-30 | 40d | 42d |  |  |  |
| 31 | 2.2.7.1 | INSTALL RACKS IN B921 |  | 4d | 2008-08-27 | 2008-09-01 |  |  |  |  | 42d | 0d | start no earlier than 2008-08-27 |  |
| 32 | 2.2.7.2 | INSTALL CABLES FROM B921 |  | 26d | 2008-09-02 | 2008-10-07 | 31 | 2000-05-08 | 2000-06-30 | 40d | 42d | 0d | start no earlier than 2008-09-02 |  |
| 33 | 2.2.7.3 | TERMINATE, TAG & TEST CABLES |  | 10d | 2008-10-08 | 2008-10-21 | 32 | 2000-05-08 | 2000-06-30 | 40d | 42d | 7d | start no earlier than 2008-10-08 |  |
| 35 | 2.2.8 | CABLE PLANT SUBSTANTIAL COMPLETION | milestone | 0d | 2008-10-31 | 2008-10-31 | 24, 28, 33 |  |  |  | 35d |  | start no earlier than 2008-10-31 |  |

| ID | WBS | Task | Type | Duration | Start | Finish | Total slack | Constraint |
| --- | --- | --- | --- | --- | --- | --- | --- | --- |
| 37 | 3 | **PH4 - MAGNET PS INSTALLATION** |  | 276d? | 2007-11-29 | 2008-12-18 | 0d |  |
| 38 | 3.1 | **B005 - BSY & LTU MAGNET PS INSTALLATION (8 Intermediate, 12 MCOR, 1 BYKIK)** |  | 121d? | 2007-11-29 | 2008-05-15 | 155d |  |
| 39 | 3.1.1 | **SAFETY PROCEDURES** |  | 15d? | 2008-03-10 | 2008-03-28 | 189d |  |
| 40 | 3.1.1.1 | Release Lockdown & Testing Procedures |  | 10d? | 2008-03-10 | 2008-03-21 | 194d | finish no earlier than 2008-03-21 |
| 41 | 3.1.1.2 | Release ELPs |  | 10d? | 2008-03-17 | 2008-03-28 | 189d | finish no earlier than 2008-03-28 |
| 42 | 3.1.2 | AC Power Available to PS Racks | milestone | 0d | 2007-11-29 | 2007-11-29 | 276d | start no earlier than 2007-11-29 |
| 43 | 3.1.3 | **Magnet Mechanical Installation** |  | 50d? | 2008-01-07 | 2008-03-14 | 199d |  |
| 44 | 3.1.3.1 | **BSY (B005) Magnet Mechanical Installation** |  | 40d? | 2008-01-07 | 2008-02-29 | 209d |  |
| 45 | 3.1.3.1.1 | magnets - Grounded |  | 40d? | 2008-01-07 | 2008-02-29 | 209d | finish no earlier than 2008-02-29 |
| 46 | 3.1.3.1.2 | magnets - Covers |  | 30d? | 2008-01-21 | 2008-02-29 | 209d | finish no earlier than 2008-02-29 |
| 47 | 3.1.3.1.3 | magnets - Alignment |  | 5d? | 2008-02-25 | 2008-02-29 | 209d | finish no earlier than 2008-02-29 |
| 48 | 3.1.3.2 | **LTU (B005) Magnet Mechanical Installation** |  | 50d? | 2008-01-07 | 2008-03-14 | 199d |  |
| 49 | 3.1.3.2.1 | magnets - Grounded |  | 40d? | 2008-01-07 | 2008-02-29 | 209d | finish no earlier than 2008-02-29 |
| 50 | 3.1.3.2.2 | magnets - Covers |  | 30d? | 2008-01-21 | 2008-02-29 | 209d | finish no earlier than 2008-02-29 |
| 51 | 3.1.3.2.3 | magnets - LCW (QVB1-3, QVM1-QVM4, BYKIK) |  | 30d? | 2008-01-21 | 2008-02-29 | 209d | finish no earlier than 2008-02-29 |
| 52 | 3.1.3.2.4 | magnets - Alignment |  | 10d? | 2008-03-03 | 2008-03-14 | 199d | start no earlier than 2008-03-03 |
| 53 | 3.1.4 | **Load Racks B005-L01 thru L06** |  | 1d? | 2007-11-29 | 2007-11-29 | 275d |  |
| 54 | 3.1.4.1 | Install PS |  | 1d? | 2007-11-29 | 2007-11-29 | 275d |  |
| 55 | 3.1.4.2 | Installl VME |  | 1d? | 2007-11-29 | 2007-11-29 | 275d |  |
| 56 | 3.1.4.3 | Install Network Hardware (Switches and Terminal Servers) |  | 1d? | 2007-11-29 | 2007-11-29 | 275d |  |
| 57 | 3.1.4.4 | Install Intra-Rack Cables |  | 1d? | 2007-11-29 | 2007-11-29 | 275d |  |
| 58 | 3.1.5 | **Control Software** |  | 53d | 2008-02-01 | 2008-04-15 | 177d |  |
| 59 | 3.1.5.1 | Databases |  | 15d | 2008-02-18 | 2008-03-07 | 204d | finish no earlier than 2008-03-07 |
| 60 | 3.1.5.2 | PLC Software and touch panels - BYKIK |  | 53d | 2008-02-01 | 2008-04-15 | 177d | finish no earlier than 2008-04-15 |
| 61 | 3.1.5.3 | Displays |  | 15d | 2008-02-18 | 2008-03-07 | 204d | finish no earlier than 2008-03-07 |
| 62 | 3.1.5.4 | Pre-installation Checkout |  | 7d | 2008-03-07 | 2008-03-17 | 198d | start no earlier than 2008-03-07 |

| ID | WBS | Task | Duration | Start | Finish | Predecessors | Total slack | Free slack | Constraint |
| --- | --- | --- | --- | --- | --- | --- | --- | --- | --- |
| 63 | 3.1.6 | **Install Long Hall Cables** | 1d? | 2007-11-29 | 2007-11-29 |  | 251d |  |  |
| 64 | 3.1.6.1 | Magnet Cables (power, klixon interlocks) | 1d? | 2007-11-29 | 2007-11-29 |  | 251d | 0d |  |
| 65 | 3.1.6.2 | Network | 1d? | 2007-11-29 | 2007-11-29 |  | 263d | 76d |  |
| 66 | 3.1.6.3 | Timing (fiber optics) | 1d? | 2007-11-29 | 2007-11-29 |  | 274d | 119d |  |
| 67 | 3.1.6.4 | TERMINATE, TAG & TEST CABLES | 1d? | 2007-11-29 | 2007-11-29 |  | 275d |  |  |
| 68 | 3.1.7 | **System Checkout (8 Intermediate, 12 MCOR, BYKIK)** | 120d? | 2007-11-30 | 2008-05-15 |  | 155d |  |  |
| 69 | 3.1.7.1 | **8 Intermediate, 12 MCOR** | 88d | 2007-11-30 | 2008-04-01 |  | 187d |  |  |
| 70 | 3.1.7.1.1 | Initial checkout and testing of magnet PS | 14d | 2007-11-30 | 2007-12-19 | 64 | 251d | 64d |  |
| 71 | 3.1.7.1.2 | Network checkout | 2d | 2008-03-17 | 2008-03-18 | 65 | 187d | 0d | start no earlier than 2008-03-17 |
| 72 | 3.1.7.1.3 | System integration | 10d | 2008-03-19 | 2008-04-01 | 70, 71 | 187d |  |  |
| 73 | 3.1.7.2 | **BYKIK** | 9d? | 2008-05-05 | 2008-05-15 |  | 155d |  |  |
| 74 | 3.1.7.2.1 | Initial checkout and testing of magnet PS | 5d? | 2008-05-05 | 2008-05-10 | 64 | 158d | 3d | finish no earlier than 2008-05-10 |
| 75 | 3.1.7.2.2 | Network checkout | 6d? | 2008-05-07 | 2008-05-14 | 65 | 155d | 0d | finish no earlier than 2008-05-14 |
| 76 | 3.1.7.2.3 | System integration | 1d? | 2008-05-15 | 2008-05-15 | 74, 75, 66 | 155d |  |  |
| 78 | 3.2 | **B911 - LTU MAGNET PS INSTALLATION (8 LGPS, 21 MCOR)** | 201d? | 2007-11-29 | 2008-09-04 |  | 75d |  |  |
| 79 | 3.2.1 | **SAFETY PROCEDURES** | 15d? | 2008-04-28 | 2008-05-16 |  | 154d |  |  |
| 80 | 3.2.1.1 | Release Lockdown & Testing Procedures | 10d? | 2008-04-28 | 2008-05-09 |  | 159d |  | start no earlier than 2008-04-28 |
| 81 | 3.2.1.2 | Release ELPs | 10d? | 2008-05-05 | 2008-05-16 |  | 154d |  | start no earlier than 2008-05-05 |
| 82 | 3.2.2 | PH4 - Install Racks in B911 | 2d | 2008-04-29 | 2008-04-30 |  | 166d |  | finish no earlier than 2008-04-30 |
| 83 | 3.2.3 | PH4 - Install AC service | 5d | 2008-05-01 | 2008-05-07 |  | 161d |  | start no earlier than 2008-05-01 |
| 84 | 3.2.4 | **Magnet and Diagnostics Installation** | 15d? | 2008-05-20 | 2008-06-09 |  | 138d |  |  |
| 85 | 3.2.4.1 | Install Magnets (Quads, Dipoles, Correctors) | 4d? | 2008-05-20 | 2008-05-23 |  | 149d |  | finish no earlier than 2008-05-23 |
| 86 | 3.2.4.2 | Connect LCW (QEM1-QEM4, QT11-43, QT12-42, QDL31-34, BX31-36) | 2d? | 2008-06-06 | 2008-06-09 |  | 138d |  | finish no earlier than 2008-06-09 |
| 87 | 3.2.5 | **Load Racks B911-10 thru B911-15** | 127d? | 2007-11-29 | 2008-05-23 |  | 149d |  |  |
| 88 | 3.2.5.1 | Install PS | 10d | 2008-05-12 | 2008-05-23 |  | 149d |  | start no earlier than 2008-05-12 |
| 89 | 3.2.5.2 | Installl VME | 1d? | 2007-11-29 | 2007-11-29 |  | 275d |  |  |
| 90 | 3.2.5.3 | Install Network Hardware (Switches and Terminal Servers) | 1d? | 2007-11-29 | 2007-11-29 |  | 275d |  |  |
| 91 | 3.2.5.4 | Install Intra-Rack Cables | 10d | 2008-05-05 | 2008-05-16 |  | 154d |  | start no earlier than 2008-05-05 |

| ID | WBS | Task | Duration | Start | Finish | Predecessors | Total slack | Free slack | Constraint |
| --- | --- | --- | --- | --- | --- | --- | --- | --- | --- |
| 92 | 3.2.6 | **Control Software** | 53d | 2008-02-01 | 2008-04-15 |  | 177d |  |  |
| 93 | 3.2.6.1 | Databases | 15d | 2008-02-18 | 2008-03-07 |  | 204d |  | finish no earlier than 2008-03-07 |
| 94 | 3.2.6.2 | PLC Software and touch panels - BYKIK | 53d | 2008-02-01 | 2008-04-15 |  | 177d |  | finish no earlier than 2008-04-15 |
| 95 | 3.2.6.3 | Displays | 15d | 2008-02-18 | 2008-03-07 |  | 204d |  | finish no earlier than 2008-03-07 |
| 96 | 3.2.6.4 | Pre-installation Checkout | 7d | 2008-03-07 | 2008-03-17 |  | 198d |  | start no earlier than 2008-03-07 |
| 97 | 3.2.7 | **Install Long Hall Cables** | 182d? | 2007-11-29 | 2008-08-08 |  | 94d |  |  |
| 98 | 3.2.7.1 | PH4 - Install Cables from B911 (power, klixon interlocks) | 20d | 2008-04-03 | 2008-04-30 |  | 166d |  | start no earlier than 2008-04-03 |
| 99 | 3.2.7.2 | Network | 1d? | 2007-11-29 | 2007-11-29 |  | 275d |  |  |
| 100 | 3.2.7.3 | Timing (fiber optics) | 1d? | 2007-11-29 | 2007-11-29 |  | 275d |  |  |
| 101 | 3.2.7.4 | PH4 - Terminate, Tag & Test Cables for LTU Areas | 40d | 2008-06-16 | 2008-08-08 |  | 75d | 0d | start no earlier than 2008-06-16 |
| 102 | 3.2.8 | **System Checkout (8 Intermediate, 21 MCOR)** | 73d | 2008-05-27 | 2008-09-04 |  | 75d |  |  |
| 103 | 3.2.8.1 | Initial checkout and testing of Magnet PS | 14d | 2008-08-11 | 2008-08-28 | 101 | 75d | 0d | start no earlier than 2008-08-11 |
| 104 | 3.2.8.2 | Network checkout | 3d | 2008-05-27 | 2008-05-29 |  | 140d | 65d | finish no earlier than 2008-05-29 |
| 105 | 3.2.8.3 | System integration | 5d | 2008-08-29 | 2008-09-04 | 103, 104 | 75d |  |  |
| 107 | 3.3 | **B912 - LTU MAGNET PS INSTALLATION (4 LGPS, 11 MCOR)** | 202d? | 2007-11-29 | 2008-09-05 |  | 74d |  |  |
| 108 | 3.3.1 | **SAFETY PROCEDURES** | 15d | 2008-05-12 | 2008-05-30 |  | 144d |  |  |
| 109 | 3.3.1.1 | Release Lockdown & Testing Procedures | 10d | 2008-05-19 | 2008-05-30 |  | 144d |  | start no earlier than 2008-05-19 |
| 110 | 3.3.1.2 | Release ELPs | 10d | 2008-05-12 | 2008-05-23 |  | 149d |  | start no earlier than 2008-05-12 |
| 111 | 3.3.2 | PH4 - Install Racks in B912 | 6d | 2008-04-29 | 2008-05-06 |  | 162d |  | finish no earlier than 2008-05-06 |
| 112 | 3.3.3 | PH4 - Install AC service | 5d | 2008-04-23 | 2008-04-29 |  | 167d |  | finish no earlier than 2008-04-29 |
| 113 | 3.3.4 | **Magnet Mechanical Installation** | 115d? | 2008-01-07 | 2008-06-13 |  | 134d |  |  |
| 114 | 3.3.4.1 | Install Magnets (Quads, Dipoles, Correctors) | 115d? | 2008-01-07 | 2008-06-13 |  | 134d |  | finish no earlier than 2008-06-13 |
| 115 | 3.3.4.2 | Connect LCW (QUM1-QUM4) | 105d? | 2008-01-21 | 2008-06-13 |  | 134d |  | finish no earlier than 2008-06-13 |
| 116 | 3.3.5 | **Load Racks B912-10 thru B912-13** | 147d? | 2007-11-29 | 2008-06-20 |  | 129d |  |  |
| 117 | 3.3.5.1 | Install PS | 10d | 2008-06-09 | 2008-06-20 |  | 129d |  | start no earlier than 2008-06-09 |
| 118 | 3.3.5.2 | Installl VME | 1d? | 2007-11-29 | 2007-11-29 |  | 275d |  |  |
| 119 | 3.3.5.3 | Install Network Hardware (Switches and Terminal Servers) | 1d? | 2007-11-29 | 2007-11-29 |  | 275d |  |  |
| 120 | 3.3.5.4 | Install Intra-Rack Cables | 10d | 2008-06-02 | 2008-06-13 |  | 134d |  | start no earlier than 2008-06-02 |

| ID | WBS | Task | Duration | Start | Finish | Predecessors | Total slack | Free slack | Constraint |
| --- | --- | --- | --- | --- | --- | --- | --- | --- | --- |
| 121 | 3.3.6 | **Control Software** | 53d | 2008-02-01 | 2008-04-15 |  | 177d |  |  |
| 122 | 3.3.6.1 | Databases | 15d | 2008-02-18 | 2008-03-07 |  | 204d |  | finish no earlier than 2008-03-07 |
| 123 | 3.3.6.2 | PLC Software and touch panels | 53d | 2008-02-01 | 2008-04-15 |  | 177d |  | finish no earlier than 2008-04-15 |
| 124 | 3.3.6.3 | Displays | 15d | 2008-02-18 | 2008-03-07 |  | 204d |  | finish no earlier than 2008-03-07 |
| 125 | 3.3.6.4 | Pre-installation Checkout | 7d | 2008-03-07 | 2008-03-17 |  | 198d |  | start no earlier than 2008-03-07 |
| 126 | 3.3.7 | **Install Long Hall Cables** | 182d? | 2007-11-29 | 2008-08-08 |  | 94d |  |  |
| 127 | 3.3.7.1 | PH4 - Install Cables from B912 (power, klixon interlocks) | 24d | 2008-04-23 | 2008-05-26 |  | 148d |  | start no earlier than 2008-04-23 |
| 128 | 3.3.7.2 | Network | 1d? | 2007-11-29 | 2007-11-29 |  | 275d |  |  |
| 129 | 3.3.7.3 | Timing (fiber optics) | 1d? | 2007-11-29 | 2007-11-29 |  | 275d |  |  |
| 130 | 3.3.7.4 | PH4 - Terminate, Tag & Test Cables for LTU Areas | 40d | 2008-06-16 | 2008-08-08 |  | 74d | 0d | finish no earlier than 2008-08-08 |
| 131 | 3.3.8 | **System Checkout (4 Intermediate, 11 MCOR)** | 20d | 2008-08-11 | 2008-09-05 |  | 74d |  |  |
| 132 | 3.3.8.1 | Initial checkout and testing of magnet PS | 10d | 2008-08-11 | 2008-08-22 | 130 | 74d | 0d | finish no earlier than 2008-08-22 |
| 133 | 3.3.8.2 | Network checkout | 3d | 2008-08-20 | 2008-08-22 |  | 74d | 0d | finish no earlier than 2008-08-22 |
| 134 | 3.3.8.3 | System integration | 10d | 2008-08-25 | 2008-09-05 | 132, 133 | 74d |  |  |
| 136 | 3.4 | **B913 - UND MAGNET PS INSTALLATION (54 MCOR)** | 262d? | 2007-11-29 | 2008-11-28 |  | 14d |  |  |
| 137 | 3.4.1 | **SAFETY PROCEDURES** | 15d | 2008-06-16 | 2008-07-04 |  | 119d |  |  |
| 138 | 3.4.1.1 | Release Lockdown & Testing Procedures | 10d | 2008-06-23 | 2008-07-04 |  | 119d |  | start no earlier than 2008-06-23 |
| 139 | 3.4.1.2 | Release ELPs | 10d | 2008-06-16 | 2008-06-27 |  | 124d |  | start no earlier than 2008-06-16 |
| 140 | 3.4.2 | PH4 - Install Racks in B913 | 6d | 2008-04-29 | 2008-05-06 |  | 162d |  | finish no earlier than 2008-05-06 |
| 141 | 3.4.3 | PH4 - Install AC service | 5d | 2008-05-05 | 2008-05-09 |  | 159d |  | finish no earlier than 2008-05-09 |
| 142 | 3.4.4 | **Magnet Mechanical Installation** | 85d? | 2008-04-07 | 2008-08-01 |  | 99d |  |  |
| 143 | 3.4.4.1 | Install Magnets (Quads, Correctors) | 85d? | 2008-04-07 | 2008-08-01 |  | 99d |  | finish no earlier than 2008-08-01 |
| 144 | 3.4.5 | **Load Racks B913-10 thru B913-11** | 172d? | 2007-11-29 | 2008-07-25 |  | 104d |  |  |
| 145 | 3.4.5.1 | Install PS | 10d | 2008-07-14 | 2008-07-25 |  | 104d |  | start no earlier than 2008-07-14 |
| 146 | 3.4.5.2 | Installl VME | 1d? | 2007-11-29 | 2007-11-29 |  | 275d |  |  |
| 147 | 3.4.5.3 | Install Network Hardware (Switches and Terminal Servers) | 1d? | 2007-11-29 | 2007-11-29 |  | 275d |  |  |
| 148 | 3.4.5.4 | Install Intra-Rack Cables | 10d | 2008-07-07 | 2008-07-18 |  | 109d |  | start no earlier than 2008-07-07 |

| ID | WBS | Task | Type | Duration | Start | Finish | Predecessors | Total slack | Free slack | Constraint |
| --- | --- | --- | --- | --- | --- | --- | --- | --- | --- | --- |
| 149 | 3.4.6 | **Control Software** |  | 53d | 2008-02-01 | 2008-04-15 |  | 177d |  |  |
| 150 | 3.4.6.1 | Databases |  | 15d | 2008-02-18 | 2008-03-07 |  | 204d |  | finish no earlier than 2008-03-07 |
| 151 | 3.4.6.2 | PLC Software and touch panels |  | 53d | 2008-02-01 | 2008-04-15 |  | 177d |  | finish no earlier than 2008-04-15 |
| 152 | 3.4.6.3 | Displays |  | 15d | 2008-02-18 | 2008-03-07 |  | 204d |  | finish no earlier than 2008-03-07 |
| 153 | 3.4.6.4 | Pre-installation Checkout |  | 7d | 2008-03-07 | 2008-03-17 |  | 198d |  | start no earlier than 2008-03-07 |
| 154 | 3.4.7 | **Install Long Hall Cables** |  | 234d? | 2007-11-29 | 2008-10-21 |  | 42d |  |  |
| 155 | 3.4.7.1 | PH4 - Install Cables from B913 (power) |  | 50d | 2008-07-22 | 2008-09-29 |  | 58d |  | start no earlier than 2008-07-22 |
| 156 | 3.4.7.2 | Network |  | 1d? | 2007-11-29 | 2007-11-29 |  | 275d |  |  |
| 157 | 3.4.7.3 | Timing (fiber optics) |  | 1d? | 2007-11-29 | 2007-11-29 |  | 275d |  |  |
| 158 | 3.4.7.4 | PH4 - Terminate, Tag & Test Cables for UND |  | 18d | 2008-09-26 | 2008-10-21 |  | 14d | 0d | finish no earlier than 2008-10-21 |
| 159 | 3.4.8 | **System Checkout (54 MCOR)** |  | 28d | 2008-10-22 | 2008-11-28 |  | 14d |  |  |
| 160 | 3.4.8.1 | Initial checkout and testing of magnet PS |  | 8d | 2008-10-22 | 2008-10-31 | 158 | 14d | 0d | finish no earlier than 2008-10-31 |
| 161 | 3.4.8.2 | Network checkout |  | 3d | 2008-10-29 | 2008-10-31 |  | 14d | 0d | finish no earlier than 2008-10-31 |
| 162 | 3.4.8.3 | System integration |  | 20d | 2008-11-03 | 2008-11-28 | 160, 161 | 14d |  | start no earlier than 2008-08-11 |
| 164 | 3.5 | **B921 - UND & DUMP MAGNET PS INSTALLATION (3 LGPS, 51 MCOR)** |  | 276d? | 2007-11-29 | 2008-12-18 |  | 0d |  |  |
| 165 | 3.5.1 | **SAFETY PROCEDURES** |  | 15d | 2008-08-04 | 2008-08-22 |  | 84d |  |  |
| 166 | 3.5.1.1 | Release Lockdown & Testing Procedures |  | 10d | 2008-08-11 | 2008-08-22 |  | 84d |  | start no earlier than 2008-08-11 |
| 167 | 3.5.1.2 | Release ELPs |  | 10d | 2008-08-04 | 2008-08-15 |  | 89d |  | start no earlier than 2008-08-04 |
| 168 | 3.5.2 | PH4 - Install Racks in B921 |  | 4d | 2008-08-27 | 2008-09-01 |  | 78d |  | start no earlier than 2008-08-27 |
| 169 | 3.5.3 | PH4 - Install AC service | milestone | 0d | 2008-05-30 | 2008-05-30 |  | 145d |  | start no earlier than 2008-05-30 |
| 170 | 3.5.4 | **Magnet Mechanical Installation** |  | 115d? | 2008-04-07 | 2008-09-12 |  | 69d |  |  |
| 171 | 3.5.4.1 | **UND (B921) Magnet Mechanical Installation** |  | 115d? | 2008-04-07 | 2008-09-12 |  | 69d |  |  |
| 172 | 3.5.4.1.1 | UND (B921) magnets - Grounded |  | 115d? | 2008-04-07 | 2008-09-12 |  | 69d |  | finish no earlier than 2008-09-12 |
| 173 | 3.5.4.1.2 | UND (B921) magnets - Covers |  | 115d? | 2008-04-07 | 2008-09-12 |  | 69d |  | finish no earlier than 2008-09-12 |
| 174 | 3.5.4.1.3 | UND (B921) magnets - Alignment |  | 115d? | 2008-04-07 | 2008-09-12 |  | 69d |  | finish no earlier than 2008-09-12 |

| ID | WBS | Task | Duration | Start | Finish | Predecessors | Total slack | Constraint |
| --- | --- | --- | --- | --- | --- | --- | --- | --- |
| 175 | 3.5.4.2 | **DUMP (B921) Magnet Mechanical Installation** | 23d? | 2008-07-07 | 2008-08-06 |  | 96d |  |
| 176 | 3.5.4.2.1 | Connect LCW (QUE1) | 1d? | 2008-08-06 | 2008-08-06 |  | 96d | finish no earlier than 2008-08-06 |
| 177 | 3.5.4.2.2 | Connect LCW (QUE2) | 1d? | 2008-07-07 | 2008-07-07 |  | 118d | finish no earlier than 2008-07-07 |
| 178 | 3.5.4.2.3 | Connect LCW (BYD1-3) | 1d? | 2008-07-09 | 2008-07-09 |  | 116d | start no earlier than 2008-07-09 |
| 179 | 3.5.4.2.4 | Connect LCW (QDMP) | 1d? | 2008-07-21 | 2008-07-21 |  | 108d | start no earlier than 2008-07-21 |
| 180 | 3.5.5 | **Load Racks B921-10 thru B921-15** | 197d? | 2007-11-29 | 2008-08-29 |  | 79d |  |
| 181 | 3.5.5.1 | Install PS | 10d | 2008-08-18 | 2008-08-29 |  | 79d | start no earlier than 2008-08-18 |
| 182 | 3.5.5.2 | Installl VME | 1d? | 2007-11-29 | 2007-11-29 |  | 275d |  |
| 183 | 3.5.5.3 | Install Network Hardware (Switches and Terminal Servers) | 1d? | 2007-11-29 | 2007-11-29 |  | 275d |  |
| 184 | 3.5.5.4 | Install Intra-Rack Cables | 10d | 2008-08-11 | 2008-08-22 |  | 84d | start no earlier than 2008-08-11 |
| 185 | 3.5.6 | **Control Software** | 53d | 2008-02-01 | 2008-04-15 |  | 177d |  |
| 186 | 3.5.6.1 | Databases | 15d | 2008-02-18 | 2008-03-07 |  | 204d | finish no earlier than 2008-03-07 |
| 187 | 3.5.6.2 | PLC Software and touch panels | 53d | 2008-02-01 | 2008-04-15 |  | 177d | finish no earlier than 2008-04-15 |
| 188 | 3.5.6.3 | Displays | 15d | 2008-02-18 | 2008-03-07 |  | 204d | finish no earlier than 2008-03-07 |
| 189 | 3.5.6.4 | Pre-installation Checkout | 7d | 2008-03-07 | 2008-03-17 |  | 198d | start no earlier than 2008-03-07 |
| 190 | 3.5.7 | **Install Long Hall Cables** | 241d? | 2007-11-29 | 2008-10-30 |  | 35d |  |
| 191 | 3.5.7.1 | PH4 - Install Cables from B921 (power, klixon interlocks) | 26d | 2008-09-11 | 2008-10-16 |  | 45d | start no earlier than 2008-09-11 |
| 192 | 3.5.7.2 | Network | 1d? | 2007-11-29 | 2007-11-29 |  | 275d |  |
| 193 | 3.5.7.3 | Timing (fiber optics) | 1d? | 2007-11-29 | 2007-11-29 |  | 275d |  |
| 194 | 3.5.7.4 | PH4 - Terminate, Tag & Test Cables for UND and DUMP | 10d | 2008-10-17 | 2008-10-30 |  | 1d | start no earlier than 2008-10-17 |
| 195 | 3.5.8 | **System Checkout (3 Intermediate, 51 MCOR)** | 34d | 2008-11-03 | 2008-12-18 |  | 0d |  |
| 196 | 3.5.8.1 | Initial checkout and testing of magnet PS | 14d | 2008-11-03 | 2008-11-20 | 194 | 0d | start no earlier than 2008-11-03 |
| 197 | 3.5.8.2 | Network checkout | 3d | 2008-11-18 | 2008-11-20 |  | 0d | finish no earlier than 2008-11-20 |
| 198 | 3.5.8.3 | System integration | 20d | 2008-11-21 | 2008-12-18 | 196, 197 | 0d | start no earlier than 2008-08-11 |
