# LCLS BC2 Magnet Controls

Schedule from MS Project, 2007-03-01 to 2007-11-30, costs in $k, A marks actual dates.
@Home

## Calendars

- Standard: Mon-Fri 08:00-12:00, 13:00-17:00; Sat-Sun off.

## Resources

| Resource | Rate |
| --- | --- |
| Engineer | 0.09 |
| Technician | 0.05 |
| Coordinator | 0.07 |
| Contract |  |

## Schedule

| ID | Task | Type | Duration | Start | Finish | Predecessors | Remaining | Total slack | Free slack | Constraint | Resources | Work | Cost |
| --- | --- | --- | --- | --- | --- | --- | --- | --- | --- | --- | --- | --- | --- |
| 1 | Start | milestone | 0w | 2007-03-01 | 2007-03-01 |  |  | 0d |  | start no earlier than 2007-03-01 |  |  |  |
| 2 | PS Controllers fabrication |  | 9w | 2007-03-01 | 2007-05-02 | 1 |  | 37d | 7d |  | Technician [25%] | 90h | 29.78 |
| 3 | PS controller bench test/EEIP |  | 5w | 2007-05-14 | 2007-06-15 | 2 |  | 30d | 15d | start no earlier than 2007-05-13 | Engineer [15%] | 30h | 2.83 |
| 4 | Optima S24 racks PO 68065 |  | 12w | 2007-03-01 | 2007-05-23 | 1 |  | 2d | 0d | start no earlier than 2007-03-01 | Engineer [10%] | 48h | 19.53 |
| 5 | Rack front views |  | 5w | 2007-03-01 | 2007-04-04 | 1 |  | 2d | 0d |  | Engineer [10%]; Coordinator [10%] | 40h | 3.2 |
| 6 | Rack accessories PO (later) |  | 7w | 2007-04-05 | 2007-05-23 | 1, 5 |  | 2d | 0d | start no earlier than 2007-04-02 | Coordinator [10%] | 28h | 34.84 |
| 7 | Rack accessories install |  | 3w | 2007-05-24 | 2007-06-13 | 4, 6 |  | 2d | 0d |  | Technician [25%] | 30h | 1.59 |
| 8 | Rack wiring - B024/B005 |  | 5w | 2007-06-14 | 2007-07-18 | 7 |  | 2d | 0d |  | Technician [75%] | 150h | 7.97 |
| 9 | PS controller install B024/B005 |  | 1w | 2007-07-09 | 2007-07-13 | 3, 7 |  | 15d |  | start no earlier than 2007-07-08 | Technician [10%] | 4h | 0.21 |
| 10 | Transductor PO 66742 |  | 2w | 2007-03-05 | 2007-03-16 | 1 |  | 75d | 0d | start no earlier than 2007-03-05 | Engineer [5%] | 4h | 12.38 |
| 11 | Transductor bench test |  | 4w | 2007-03-19 | 2007-04-13 | 10 |  | 75d | 50d |  | Technician [10%] | 16h | 0.85 |
| 12 | Transductor install B024/B005 |  | 1w | 2007-06-25 | 2007-06-29 | 11, 7 |  | 25d |  | start no earlier than 2007-06-24 | Technician [10%] | 4h | 0.21 |
| 13 | IE Power PS PO 67820 |  | 19.4w | 2007-03-01 | 2007-07-13 | 1 |  | 0d |  | start no earlier than 2007-03-01 | Engineer [5%] | 38.8h | 103.66 |
| 14 | IE Power PS bench test/EEIP |  | 2w | 2007-07-16 | 2007-07-27 | 13 |  | 0d |  | start no earlier than 2007-07-14 | Technician [25%] | 20h | 1.06 |
| 15 | IE Power PS install B024/B005 |  | 1w | 2007-07-30 | 2007-08-03 | 14 |  | 0d |  | start no earlier than 2007-07-29 | Technician [25%] | 10h | 0.53 |
| 16 | IE Power systems test |  | 2w | 2007-08-06 | 2007-08-17 | 15, 9, 12 |  | 0d |  | start no earlier than 2007-08-04 | Engineer [25%]; Technician [25%] | 40h | 2.95 |
| 17 | BiRa MCORs PO (later) |  | 12w | 2007-03-09 | 2007-05-31 | 1 |  | 11d | 0d | start no earlier than 2007-03-09 | Engineer [10%] | 48h | 50.33 |
| 18 | BiRa MCORs bench test/EEIP |  | 4w | 2007-06-01 | 2007-06-28 | 17 |  | 11d | 0d |  | Technician [10%] | 16h | 0.85 |
| 19 | BiRa MCORs install B024/B005 |  | 1w | 2007-06-29 | 2007-07-05 | 18 |  | 11d | 9d |  | Technician [10%] | 4h | 0.21 |
| 20 | EMI MCOR bulks PO 66507 |  | 3w | 2007-03-01 | 2007-03-21 | 1 |  | 65d | 0d |  | Coordinator [5%] | 6h | 13.39 |
| 21 | EMI MCOR bulks bench test/EEIP |  | 3w | 2007-03-26 | 2007-04-13 | 20 |  | 65d | 0d |  | Technician [25%] | 30h | 1.59 |
| 22 | EMI MCOR bulks install B024/B005 |  | 1w | 2007-04-16 | 2007-04-20 | 21 |  | 65d | 63d |  | Technician [10%] | 4h | 0.21 |
| 23 | MCOR PLC PO |  | 5w | 2007-04-23 | 2007-05-25 | 22 |  | 25d | 0d |  | Engineer [10%] | 20h | 13.89 |
| 24 | MCOR PLC install |  | 3w | 2007-05-28 | 2007-06-15 | 23 |  | 25d | 23d |  | Technician [50%] | 60h | 3.19 |
| 25 | MCOR system tests |  | 4w | 2007-07-19 | 2007-08-15 | 8, 19, 24 |  | 2d |  | start no earlier than 2007-03-05 | Engineer [33.3%]; Technician [50%]; Coordinator [33.3%] | 186.67h | 12.78 |
| 26 | BXKIK prototype fab and test |  | 4w | 2007-04-03 | 2007-04-30 | 1 |  | 34d | 33d | start no earlier than 2007-04-03 | Engineer [25%]; Technician [25%]; Coordinator | 80h | 5.9 |
| 27 | BXKIK Kicker ESD |  | 4w | 2007-03-28 | 2007-04-24 | 1 |  | 18d | 17d | start no earlier than 2007-03-28 | Engineer [25%] | 40h | 3.77 |
| 28 | BXKIK elect/mech design |  | 4w | 2007-05-18 | 2007-06-14 | 27 |  | 121d |  | start no earlier than 2007-05-18 | Engineer [25%]; Technician [25%] | 80h | 5.9 |
| 29 | BXKIK purchase |  | 3w | 2007-06-15 | 2007-07-05 | 28, 26 |  | 1d | 0d | start no earlier than 2007-06-02 | Engineer [10%]; Technician [25%]; Coordinator [10%] | 54h | 35.51 |
| 30 | BXKIK PLC PO |  | 6w | 2007-05-24 | 2007-07-04 | 6 |  | 2d | 0d |  | Engineer [10%] | 24h | 8.27 |
| 31 | BXKIK fab in rack/EEIP |  | 3w | 2007-07-06 | 2007-07-26 | 30, 29 |  | 1d | 0d |  | Technician [50%]; Coordinator [10%] | 72h | 3.98 |
| 32 | BXKIK tests in B024 |  | 3w | 2007-07-27 | 2007-08-16 | 31 |  | 1d |  | start no earlier than 2007-07-17 | Engineer [25%]; Technician [25%]; Coordinator [10%] | 72h | 5.21 |
| 33 | EI diagrams |  | 7w | 2007-03-26 | 2007-05-11 | 1 |  | 30d | 25d | start no earlier than 2007-03-25 | Engineer [10%]; Coordinator [25%] | 98h | 7.24 |
| 34 | CAPTAR for cables |  | 6w | 2007-06-18 | 2007-07-27 | 33 |  | 5d | 0d | start no earlier than 2007-06-17 | Coordinator [25%] | 60h | 3.94 |
| 35 | CAPTAR for racks |  | 4w | 2007-07-30 | 2007-08-24 | 34 |  | 5d |  | start no earlier than 2007-05-20 | Engineer [5%]; Coordinator [50%] | 88h | 6 |
| 36 | Field install racks B024 |  | 1w | 2007-08-20 | 2007-08-24 | 25, 16, 32 |  | 0d |  |  | Contract |  |  |
| 37 | AC power B024/B005 |  | 1w | 2007-08-27 | 2007-08-31 | 36 |  | 0d |  | start no earlier than 2007-08-26 | Contract |  |  |
| 38 | Test Procedures |  | 4w | 2007-07-02 | 2007-07-27 | 1 |  | 25d |  | start no earlier than 2007-07-02 | Engineer [25%]; Coordinator [25%] | 80h | 6.4 |
| 39 | ELPs |  | 4w | 2007-07-26 | 2007-08-22 | 1 |  | 7d |  | start no earlier than 2007-07-26 | Coordinator [25%] | 40h | 2.62 |
| 40 | Summer shutdown | milestone | 0w | 2007-09-01 | 2007-09-01 | 37, 38, 39, 35, 34 |  | 0d |  | start no earlier than 2007-09-01 |  |  |  |
| 41 | Long haul cables pull and terminate |  | 13w | 2007-09-03 A | 2007-11-30 | 40 | 13w | 0d |  |  | Contract | 520h |  |
| 42 | Field test IE Power systems B024/B005 |  | 7w | 2007-09-03 | 2007-10-19 | 40 |  | 30d |  |  | Engineer [25%]; Technician [50%] | 210h | 14.04 |
| 43 | Field test MCOR systems B024/B005 |  | 7w | 2007-09-03 | 2007-10-19 | 40 |  | 30d |  |  | Engineer [25%]; Technician [50%]; Coordinator [25%] | 280h | 18.64 |
| 44 | Field test BXKIK kicker B024 |  | 13w | 2007-09-03 | 2007-11-30 | 40 |  | 0d |  |  | Engineer [10%]; Technician [10%]; Coordinator [10%] | 156h | 11.08 |
| 45 | End | milestone | 0w | 2007-11-30 | 2007-11-30 | 42, 43, 41, 44 |  | 0d |  |  |  |  |  |
